# SV_AC

Schedule from MS Project, 2007-11-12 to 2008-02-26.
Windows XP Bundled build Engineering Computing

## Calendars

- Standard: Mon-Fri 08:00-12:00, 13:00-17:00; Sat-Sun off.

## Resources

| Resource |
| --- |
| DB |
| DK |
| BT |
| LP |
| JH |
| MK |
| ES |
| EC |

## Schedule

| ID | WBS | Task | Duration | Start | Finish | Predecessors | Total slack | Free slack | Constraint | Resources | Work | Text1 | Text2 | Text5 | Text6 | Text19 |
| --- | --- | --- | --- | --- | --- | --- | --- | --- | --- | --- | --- | --- | --- | --- | --- | --- |
| 1 | 1 | **1932** | 7d? | 2007-11-12 | 2007-11-20 |  | 70d |  |  | DB | 56h | 46'07 | 47'07 | NA | NA | ww46 '07 |
| 2 | 1.1 | draft | 1d? | 2007-11-12 | 2007-11-12 |  | 76d |  |  |  |  | 46'07 | 46'07 | NA | NA | ww46 '07 |
| 3 | 1.2 | review | 1d? | 2007-11-12 | 2007-11-12 |  | 76d |  |  |  |  | 46'07 | 46'07 | NA | NA | ww46 '07 |
| 4 | 1.3 | ballot & revision | 1.4w | 2007-11-12 | 2007-11-20 |  | 70d |  | finish no earlier than 2007-11-20 |  |  | 46'07 | 47'07 | NA | NA | ww47 '07 |
| 5 | 2 | **1900** | 17d? | 2007-11-12 | 2007-12-04 |  | 60d |  |  | DK | 136h | 46'07 | 49'07 | NA | NA | ww46 '07 |
| 6 | 2.1 | draft | 1d? | 2007-11-12 | 2007-11-12 |  | 76d |  |  |  |  | 46'07 | 46'07 | NA | NA | ww46 '07 |
| 7 | 2.2 | review | 0.4w | 2007-11-12 | 2007-11-13 |  | 60d | 0d | start no earlier than 2007-11-12 |  |  | 46'07 | 46'07 | NA | NA | ww46 '07 |
| 8 | 2.3 | ballot & revision | 3w | 2007-11-14 | 2007-12-04 | 7 | 60d |  | finish no earlier than 2007-12-04 |  |  | 46'07 | 49'07 | NA | NA | ww49 '07 |
| 9 | 3 | **1757** | 7d? | 2007-11-12 | 2007-11-20 |  | 70d |  |  | DB | 56h | 46'07 | 47'07 | NA | NA | ww49 '07 |
| 10 | 3.1 | ballot & revision | 7d? | 2007-11-12 | 2007-11-20 |  | 70d |  | start no earlier than 2007-11-12 |  |  | 46'07 | 47'07 | NA | NA | ww47 '07 |
| 11 | 4 | **1898** | 17d? | 2007-11-12 | 2007-12-04 |  | 60d |  |  | BT | 136h | 46'07 | 49'07 | NA | NA | ww46 '07 |
| 12 | 4.1 | review | 7d? | 2007-11-12 | 2007-11-20 |  | 60d | 0d | start no earlier than 2007-11-12 |  |  | 46'07 | 47'07 | NA | NA | ww47 '07 |
| 13 | 4.2 | ballot & revision | 10d? | 2007-11-21 | 2007-12-04 | 12 | 60d |  |  |  |  | 47'07 | 49'07 | NA | NA | ww49 '07 |
| 14 | 5 | **1756** | 21d | 2007-11-13 | 2007-12-11 |  | 55d |  |  | DK | 168h | 46'07 | 50'07 | NA | NA | ww46 '07 |
| 15 | 5.1 | ballot & revision | 21d | 2007-11-13 | 2007-12-11 |  | 55d |  | finish no earlier than 2007-12-11 |  |  | 46'07 | 50'07 | NA | NA | ww50 '07 |
| 16 | 6 | **1682** | 7d | 2007-11-12 | 2007-11-20 |  | 70d |  |  | DK | 56h | 46'07 | 47'07 | NA | NA | ww46 '07 |
| 17 | 6.1 | ballot & revision | 7d | 2007-11-12 | 2007-11-20 |  | 70d |  | start no earlier than 2007-11-12 |  |  | 46'07 | 47'07 | NA | NA | ww47 '07 |
| 18 | 7 | **2171** | 10d | 2007-11-14 | 2007-11-27 |  | 65d |  |  | DK | 80h | 46'07 | 48'07 | NA | NA | ww46 '07 |
| 19 | 7.1 | review | 5d | 2007-11-14 | 2007-11-20 |  | 65d | 0d | start no earlier than 2007-11-14 |  |  | 46'07 | 47'07 | NA | NA | ww47 '07 |
| 20 | 7.2 | ballot & revision | 5d | 2007-11-21 | 2007-11-27 | 19 | 65d |  | finish no earlier than 2007-11-27 |  |  | 47'07 | 48'07 | NA | NA | ww48 '07 |
| 21 | 8 | **1503** | 20d? | 2007-11-14 | 2007-12-11 |  | 55d |  |  | LP | 160h | 46'07 | 50'07 | NA | NA | ww46 '07 |
| 22 | 8.1 | draft | 5d? | 2007-11-14 | 2007-11-20 |  | 55d | 0d | start no earlier than 2007-11-14 |  |  | 46'07 | 47'07 | NA | NA | ww47 '07 |
| 23 | 8.2 | ballot & revision | 15d | 2007-11-21 | 2007-12-11 | 22 | 55d |  | start no earlier than 2007-11-21 |  |  | 47'07 | 50'07 | NA | NA | ww50 '07 |
| 24 | 9 | **2033** | 11d? | 2007-11-13 | 2007-11-27 |  | 65d |  |  |  |  | 46'07 | 48'07 | NA | NA | ww46 '07 |
| 25 | 9.1 | review | 6d? | 2007-11-13 | 2007-11-20 |  | 65d | 0d | start no earlier than 2007-11-13 |  |  | 46'07 | 47'07 | NA | NA | ww47 '07 |
| 26 | 9.2 | ballot & revision | 5d? | 2007-11-21 | 2007-11-27 | 25 | 65d |  |  |  |  | 47'07 | 48'07 | NA | NA | ww48 '07 |

| ID | WBS | Task | Duration | Start | Finish | Predecessors | Total slack | Free slack | Constraint | Resources | Work | Text1 | Text2 | Text5 | Text6 | Text19 |
| --- | --- | --- | --- | --- | --- | --- | --- | --- | --- | --- | --- | --- | --- | --- | --- | --- |
| 27 | 10 | **1667** | 40d? | 2007-11-21 | 2008-01-15 |  | 30d |  |  | JH | 320h | 47'07 | 3'08 | NA | NA | ww46 '07 |
| 28 | 10.1 | draft | 10d? | 2007-11-21 | 2007-12-04 |  | 30d | 0d | start no earlier than 2007-11-21 |  |  | 47'07 | 49'07 | NA | NA | ww49 '07 |
| 29 | 10.2 | review | 10d? | 2007-12-05 | 2007-12-18 | 28 | 30d | 0d |  |  |  | 49'07 | 51'07 | NA | NA | ww51 '07 |
| 30 | 10.3 | ballot & revision | 20d? | 2007-12-19 | 2008-01-15 | 29 | 30d |  | start no earlier than 2007-12-19 |  |  | 51'07 | 3'08 | NA | NA | ww03 '08 |
| 31 | 11 | **1683** | 40d? | 2007-11-21 | 2008-01-15 |  | 30d |  |  | DK | 320h | 47'07 | 3'08 | NA | NA | ww46 '07 |
| 32 | 11.1 | draft | 10d? | 2007-11-21 | 2007-12-04 |  | 30d | 0d | start no earlier than 2007-11-21 |  |  | 47'07 | 49'07 | NA | NA | ww49 '07 |
| 33 | 11.2 | review | 10d? | 2007-12-05 | 2007-12-18 | 32 | 30d | 0d |  |  |  | 49'07 | 51'07 | NA | NA | ww51 '07 |
| 34 | 11.3 | ballot & revision | 20d | 2007-12-19 | 2008-01-15 | 33 | 30d |  | start no earlier than 2007-12-19 |  |  | 51'07 | 3'08 | NA | NA | ww03 '08 |
| 35 | 12 | **2150** | 40d? | 2007-11-28 | 2008-01-22 |  | 25d |  |  | MK | 320h | 48'07 | 4'08 | NA | NA | ww49 '07 |
| 36 | 12.1 | draft | 5d? | 2007-11-28 | 2007-12-04 |  | 25d | 0d | start no earlier than 2007-11-28 |  |  | 48'07 | 49'07 | NA | NA | ww49 '07 |
| 37 | 12.2 | review | 10d? | 2007-12-05 | 2007-12-18 | 36 | 25d | 0d | start no earlier than 2007-12-05 |  |  | 49'07 | 51'07 | NA | NA | ww51 '07 |
| 38 | 12.3 | ballot & revision | 25d? | 2007-12-19 | 2008-01-22 | 37 | 25d |  | start no earlier than 2007-12-19 |  |  | 51'07 | 4'08 | NA | NA | ww04 '08 |
| 39 | 13 | **1995** | 15d | 2007-11-28 | 2007-12-18 |  | 50d |  |  | ES | 120h | 48'07 | 51'07 | NA | NA | ww46 '07 |
| 40 | 13.1 | ballot & revision | 15d | 2007-11-28 | 2007-12-18 |  | 50d |  | finish no earlier than 2007-12-18 |  |  | 48'07 | 51'07 | NA | NA | ww51 '07 |
| 41 | 14 | **2005** | 40d? | 2007-12-12 | 2008-02-05 |  | 15d |  |  | ES | 320h | 50'07 | 6'08 | NA | NA | ww46 '07 |
| 42 | 14.1 | review | 30d? | 2007-12-12 | 2008-01-22 |  | 15d | 0d | start no earlier than 2007-12-12 |  |  | 50'07 | 4'08 | NA | NA | ww04 '08 |
| 43 | 14.2 | ballot & revision | 10d | 2008-01-23 | 2008-02-05 | 42 | 15d |  | start no earlier than 2008-01-23 |  |  | 4'08 | 6'08 | NA | NA | ww06 '08 |
| 44 | 15 | **1786** | 10d? | 2007-12-05 | 2007-12-18 |  | 50d |  |  | DB | 80h | 49'07 | 51'07 | NA | NA | ww46 '07 |
| 45 | 15.1 | review | 5d? | 2007-12-05 | 2007-12-11 |  | 50d | 0d | start no earlier than 2007-12-05 |  |  | 49'07 | 50'07 | NA | NA | ww50 '07 |
| 46 | 15.2 | ballot & revision | 5d | 2007-12-12 | 2007-12-18 | 45 | 50d |  | start no earlier than 2007-12-12 |  |  | 50'07 | 51'07 | NA | NA | ww51 '07 |
| 47 | 16 | **2172** | 25d? | 2007-12-05 | 2008-01-08 |  | 35d |  |  | JH | 200h | 49'07 | 2'08 | NA | NA | ww46 '07 |
| 48 | 16.1 | draft | 5d? | 2007-12-05 | 2007-12-11 |  | 35d | 0d | start no earlier than 2007-12-05 |  |  | 49'07 | 50'07 | NA | NA | ww50 '07 |
| 49 | 16.2 | review | 5d? | 2007-12-12 | 2007-12-18 | 48 | 35d | 0d | start no earlier than 2007-12-12 |  |  | 50'07 | 51'07 | NA | NA | ww51 '07 |
| 50 | 16.3 | ballot & revision | 15d | 2007-12-19 | 2008-01-08 | 49 | 35d |  | start no earlier than 2007-12-19 |  |  | 51'07 | 2'08 | NA | NA | ww02 '08 |

| ID | WBS | Task | Duration | Start | Finish | Predecessors | Total slack | Free slack | Constraint | Resources | Work | Text1 | Text2 | Text5 | Text6 | Text19 |
| --- | --- | --- | --- | --- | --- | --- | --- | --- | --- | --- | --- | --- | --- | --- | --- | --- |
| 51 | 17 | **1627** | 25d? | 2007-12-12 | 2008-01-15 |  | 30d |  |  | DK | 200h | 50'07 | 3'08 | NA | NA | ww46 '07 |
| 52 | 17.1 | draft | 5d? | 2007-12-12 | 2007-12-18 |  | 30d | 0d | start no earlier than 2007-12-12 |  |  | 50'07 | 51'07 | NA | NA | ww51 '07 |
| 53 | 17.2 | review | 15d | 2007-12-19 | 2008-01-08 | 52 | 30d | 0d | start no earlier than 2007-12-19 |  |  | 51'07 | 2'08 | NA | NA | ww02 '08 |
| 54 | 17.3 | ballot & revision | 5d | 2008-01-09 | 2008-01-15 | 53 | 30d |  | start no earlier than 2008-01-09 |  |  | 2'08 | 3'08 | NA | NA | ww03 '08 |
| 55 | 18 | **1769** | 15d? | 2008-01-02 | 2008-01-22 |  | 25d |  |  | EC | 120h | 1'08 | 4'08 | NA | NA | ww46 '07 |
| 56 | 18.1 | review | 5d? | 2008-01-02 | 2008-01-08 |  | 25d | 0d | start no earlier than 2008-01-02 |  |  | 1'08 | 2'08 | NA | NA | ww02 '08 |
| 57 | 18.2 | ballot & revision | 10d? | 2008-01-09 | 2008-01-22 | 56 | 25d |  |  |  |  | 2'08 | 4'08 | NA | NA | ww04 '08 |
| 58 | 19 | **1686** | 10d? | 2008-01-02 | 2008-01-15 |  | 30d |  |  | JH | 80h | 1'08 | 3'08 | NA | NA | ww46 '07 |
| 59 | 19.1 | review | 5d? | 2008-01-02 | 2008-01-08 |  | 30d | 0d | start no earlier than 2008-01-02 |  |  | 1'08 | 2'08 | NA | NA | ww02 '08 |
| 60 | 19.2 | ballot & revision | 5d? | 2008-01-09 | 2008-01-15 | 59 | 30d |  | finish no earlier than 2008-01-15 |  |  | 2'08 | 3'08 | NA | NA | ww03 '08 |
| 61 | 20 | **2173** | 25d? | 2008-01-02 | 2008-02-05 |  | 15d |  |  | JH | 200h | 1'08 | 6'08 | NA | NA | ww46 '07 |
| 62 | 20.1 | draft | 10d? | 2008-01-02 | 2008-01-15 |  | 15d | 0d | start no earlier than 2008-01-02 |  |  | 1'08 | 3'08 | NA | NA | ww03 '08 |
| 63 | 20.2 | review | 5d? | 2008-01-16 | 2008-01-22 | 62 | 15d | 0d | finish no earlier than 2008-01-22 |  |  | 3'08 | 4'08 | NA | NA | ww04 '08 |
| 64 | 20.3 | ballot & revision | 10d? | 2008-01-23 | 2008-02-05 | 63 | 15d |  | finish no earlier than 2008-02-05 |  |  | 4'08 | 6'08 | NA | NA | ww06 '08 |
| 65 | 21 | **2069** | 35d? | 2008-01-02 | 2008-02-19 |  | 5d |  |  | DK | 280h | 1'08 | 8'08 | NA | NA | ww46 '07 |
| 66 | 21.1 | draft | 10d? | 2008-01-02 | 2008-01-15 |  | 5d | 0d | finish no earlier than 2008-01-15 |  |  | 1'08 | 3'08 | NA | NA | ww03 '08 |
| 67 | 21.2 | review | 10d? | 2008-01-16 | 2008-01-29 | 66 | 5d | 0d | finish no earlier than 2008-01-29 |  |  | 3'08 | 5'08 | NA | NA | ww05 '08 |
| 68 | 21.3 | ballot & revision | 15d? | 2008-01-30 | 2008-02-19 | 67 | 5d |  | finish no earlier than 2008-02-19 |  |  | 5'08 | 8'08 | NA | NA | ww08 '08 |
| 69 | 22 | **1901** | 15d? | 2008-01-02 | 2008-01-22 |  | 25d |  |  | EC | 120h | 1'08 | 4'08 | NA | NA | ww46 '07 |
| 70 | 22.1 | draft | 5d? | 2008-01-02 | 2008-01-08 |  | 25d | 0d | start no earlier than 2008-01-02 |  |  | 1'08 | 2'08 | NA | NA | ww02 '08 |
| 71 | 22.2 | review | 5d? | 2008-01-09 | 2008-01-15 | 70 | 25d | 0d | finish no earlier than 2008-01-15 |  |  | 2'08 | 3'08 | NA | NA | ww03 '08 |
| 72 | 22.3 | ballot & revision | 5d? | 2008-01-16 | 2008-01-22 | 71 | 25d |  | finish no earlier than 2008-01-22 |  |  | 3'08 | 4'08 | NA | NA | ww04 '08 |
| 73 | 23 | **1982** | 25d? | 2008-01-09 | 2008-02-12 |  | 10d |  |  | JH | 200h | 2'08 | 7'08 | NA | NA | ww46 '07 |
| 74 | 23.1 | draft | 10d? | 2008-01-09 | 2008-01-22 |  | 10d | 0d | start no earlier than 2008-01-09 |  |  | 2'08 | 4'08 | NA | NA | ww04 '08 |
| 75 | 23.2 | review | 5d? | 2008-01-23 | 2008-01-29 | 74 | 10d | 0d | finish no earlier than 2008-01-29 |  |  | 4'08 | 5'08 | NA | NA | ww05 '08 |
| 76 | 23.3 | ballot & revision | 10d? | 2008-01-30 | 2008-02-12 | 75 | 10d |  | finish no earlier than 2008-02-12 |  |  | 5'08 | 7'08 | NA | NA | ww07 '08 |

| ID | WBS | Task | Duration | Start | Finish | Predecessors | Total slack | Free slack | Constraint | Resources | Work | Text1 | Text2 | Text5 | Text6 | Text19 |
| --- | --- | --- | --- | --- | --- | --- | --- | --- | --- | --- | --- | --- | --- | --- | --- | --- |
| 77 | 24 | **2110** | 20d? | 2008-01-09 | 2008-02-05 |  | 15d |  |  | ES | 160h | 2'08 | 6'08 | NA | NA | ww46 '07 |
| 78 | 24.1 | draft | 5d? | 2008-01-09 | 2008-01-15 |  | 15d | 0d | start no earlier than 2008-01-09 |  |  | 2'08 | 3'08 | NA | NA | ww03 '08 |
| 79 | 24.2 | review | 5d? | 2008-01-16 | 2008-01-22 | 78 | 15d | 0d | finish no earlier than 2008-01-22 |  |  | 3'08 | 4'08 | NA | NA | ww04 '08 |
| 80 | 24.3 | ballot & revision | 10d? | 2008-01-23 | 2008-02-05 | 79 | 15d |  | finish no earlier than 2008-02-05 |  |  | 4'08 | 6'08 | NA | NA | ww06 '08 |
| 81 | 25 | **1987** | 15d? | 2008-01-09 | 2008-01-29 |  | 20d |  |  | JH | 120h | 2'08 | 5'08 | NA | NA | ww46 '07 |
| 82 | 25.1 | draft | 5d? | 2008-01-09 | 2008-01-15 |  | 20d | 0d | start no earlier than 2008-01-09 |  |  | 2'08 | 3'08 | NA | NA | ww03 '08 |
| 83 | 25.2 | review | 5d? | 2008-01-16 | 2008-01-22 | 82 | 20d | 0d | finish no earlier than 2008-01-22 |  |  | 3'08 | 4'08 | NA | NA | ww04 '08 |
| 84 | 25.3 | ballot & revision | 5d? | 2008-01-23 | 2008-01-29 | 83 | 20d |  | finish no earlier than 2008-01-29 |  |  | 4'08 | 5'08 | NA | NA | ww05 '08 |
| 85 | 26 | **2100** | 20d? | 2008-01-16 | 2008-02-12 |  | 10d |  |  | DK | 160h | 3'08 | 7'08 | NA | NA | ww46 '07 |
| 86 | 26.1 | draft | 5d? | 2008-01-16 | 2008-01-22 |  | 10d | 0d | start no earlier than 2008-01-16 |  |  | 3'08 | 4'08 | NA | NA | ww04 '08 |
| 87 | 26.2 | review | 5d? | 2008-01-23 | 2008-01-29 | 86 | 10d | 0d | finish no earlier than 2008-01-29 |  |  | 4'08 | 5'08 | NA | NA | ww05 '08 |
| 88 | 26.3 | ballot & revision | 10d? | 2008-01-30 | 2008-02-12 | 87 | 10d |  | finish no earlier than 2008-02-12 |  |  | 5'08 | 7'08 | NA | NA | ww07 '08 |
| 89 | 27 | **1830** | 15d? | 2008-01-16 | 2008-02-05 |  | 15d |  |  | JH | 120h | 3'08 | 6'08 | NA | NA | ww46 '07 |
| 90 | 27.1 | draft | 5d? | 2008-01-16 | 2008-01-22 |  | 15d | 0d | start no earlier than 2008-01-16 |  |  | 3'08 | 4'08 | NA | NA | ww04 '08 |
| 91 | 27.2 | review | 5d? | 2008-01-23 | 2008-01-29 | 90 | 15d | 0d | finish no earlier than 2008-01-29 |  |  | 4'08 | 5'08 | NA | NA | ww05 '08 |
| 92 | 27.3 | ballot & revision | 5d? | 2008-01-30 | 2008-02-05 | 91 | 15d |  | finish no earlier than 2008-02-05 |  |  | 5'08 | 6'08 | NA | NA | ww06 '08 |
| 93 | 28 | **1806** | 20d? | 2008-01-23 | 2008-02-19 |  | 5d |  |  | EC | 160h | 4'08 | 8'08 | NA | NA | ww46 '07 |
| 94 | 28.1 | draft | 5d? | 2008-01-23 | 2008-01-29 |  | 5d | 0d | start no earlier than 2008-01-23 |  |  | 4'08 | 5'08 | NA | NA | ww05 '08 |
| 95 | 28.2 | review | 10d? | 2008-01-30 | 2008-02-12 | 94 | 5d | 0d | finish no earlier than 2008-02-12 |  |  | 5'08 | 7'08 | NA | NA | ww07 '08 |
| 96 | 28.3 | ballot & revision | 5d? | 2008-02-13 | 2008-02-19 | 95 | 5d |  | start no earlier than 2008-02-13 |  |  | 7'08 | 8'08 | NA | NA | ww08 '08 |
| 97 | 29 | **1551** | 15d? | 2008-02-06 | 2008-02-26 |  | 0d |  |  | DK | 120h | 6'08 | 9'08 | NA | NA | ww46 '07 |
| 98 | 29.1 | review | 5d? | 2008-02-06 | 2008-02-12 |  | 0d |  | start no earlier than 2008-02-06 |  |  | 6'08 | 7'08 | NA | NA | ww07 '08 |
| 99 | 29.2 | ballot & revision | 10d? | 2008-02-13 | 2008-02-26 | 98 | 0d |  | finish no earlier than 2008-02-26 |  |  | 7'08 | 9'08 | NA | NA | ww09 '08 |
